# Cedarline Pump Station Retrofit (SYNTHETIC EXAMPLE)

How a schedule from Primavera P6 changed from version to version. A marks actual dates.

## Version 1 (data date 2025-02-03, saved 2026-08-17, file CEDARLINE-BL-2025-02-03.xer)

| ID | WBS | Task | Duration | Start | Finish | Predecessors | Total float |
| --- | --- | --- | --- | --- | --- | --- | --- |
|  | PRE | **Preconstruction** |  | 2025-02-03 | 2025-03-04 |  |  |
| MS-NTP |  | Notice to Proceed | 0d | 2025-02-03 | 2025-02-03 |  | 0d |
| PRE-MOB |  | Mobilize Site Offices and Laydown | 5d | 2025-02-03 | 2025-02-10 | MS-NTP | 17d |
| PRE-PERMIT |  | Building Permit Issuance | 20d | 2025-02-03 | 2025-03-04 | MS-NTP | 0d |
| PRE-SHOP |  | Structural Shop Drawings and Review | 15d | 2025-02-03 | 2025-02-25 | MS-NTP | 27d |
|  | CIV | **Civil and Structural** |  | 2025-02-10 | 2025-05-30 |  |  |
| CIV-SOE |  | Shoring and Dewatering Install | 8d | 2025-02-10 | 2025-02-21 | PRE-MOB | 203d |
| CIV-EXC |  | Bulk Excavation Wet Well | 10d | 2025-03-04 | 2025-03-18 | PRE-PERMIT, CIV-SOE SS+3d | 0d |
| CIV-MUD |  | Mud Slab and Survey Layout | 4d | 2025-03-18 | 2025-03-24 | CIV-EXC | 0d |
| CIV-BASE |  | Form Reinforce and Pour Base Slab | 12d | 2025-03-24 | 2025-04-09 | CIV-MUD, PRE-SHOP | 0d |
| CIV-WALL |  | Form Reinforce and Pour Wet Well Walls | 14d | 2025-04-09 | 2025-04-30 | CIV-BASE | 0d |
| CIV-CURE |  | Wall Cure and Strip Formwork | 7d | 2025-04-30 | 2025-05-09 | CIV-WALL | 0d |
| CIV-BKF |  | Backfill and Compact Around Structure | 6d | 2025-05-09 | 2025-05-20 | MS-CONC | 2d |
| MS-CONC |  | Concrete Structure Complete | 0d | 2025-05-09 | 2025-05-09 | CIV-CURE | 0d |
| CIV-SLAB |  | Grade Slab and Equipment Pads | 8d | 2025-05-20 | 2025-05-30 | CIV-BKF | 4d |
|  | MEC | **Mechanical** |  | 2025-02-03 | 2025-07-03 |  |  |
| MEC-PROC |  | Pump Skid Fabrication and Delivery | 40d | 2025-02-03 | 2025-04-01 | MS-NTP | 65d |
| MEC-SET |  | Set Pump Skids and Grout Baseplates | 8d | 2025-05-09 | 2025-05-22 | MS-CONC, MEC-PROC | 26d |
| MEC-PIPE |  | Internal Process Piping Install | 18d | 2025-05-22 | 2025-06-17 | MEC-SET | 27d |
| MEC-VALVE |  | Valve and Actuator Install | 6d | 2025-06-17 | 2025-06-25 | MEC-PIPE | 27d |
| MEC-TEST |  | Hydrostatic Test Process Piping | 5d | 2025-06-25 | 2025-07-03 | MEC-VALVE | 26d |
|  | ELE | **Electrical** |  | 2025-02-03 | 2025-07-29 |  |  |
| ELE-PROC |  | MCC and VFD Fabrication and Delivery | 35d | 2025-02-03 | 2025-03-25 | MS-NTP | 90d |
| ELE-COND |  | Conduit and Cable Tray Rough-In | 14d | 2025-06-03 | 2025-06-23 | CIV-SLAB, BLD-ROOF | 0d |
| ELE-MCC |  | Set MCC and VFD Line-Up | 5d | 2025-06-23 | 2025-06-30 | ELE-PROC, ELE-COND | 0d |
| ELE-CABLE |  | Power and Control Cable Pull | 12d | 2025-06-30 | 2025-07-17 | ELE-MCC | 0d |
| ELE-TERM |  | Terminate and Point-to-Point Check | 8d | 2025-07-17 | 2025-07-29 | ELE-CABLE | 0d |
| MS-ENERG |  | Permanent Power Energized | 0d | 2025-07-29 | 2025-07-29 | ELE-TERM | 0d |
|  | BLD | **Building Envelope** |  | 2025-02-03 | 2025-06-19 |  |  |
| BLD-PROC |  | Pre-Engineered Building Delivery | 30d | 2025-02-03 | 2025-03-18 | MS-NTP | 52d |
| BLD-ERECT |  | Erect Pre-Engineered Building Frame | 10d | 2025-05-09 | 2025-05-26 | MS-CONC, BLD-PROC | 0d |
| BLD-ROOF |  | Roof Deck and Membrane | 6d | 2025-05-26 | 2025-06-03 | BLD-ERECT | 0d |
| BLD-CLAD |  | Wall Cladding and Flashing | 8d | 2025-06-03 | 2025-06-13 | BLD-ROOF | 87d |
| BLD-DOOR |  | Overhead Doors and Louvres | 4d | 2025-06-13 | 2025-06-19 | BLD-CLAD | 85d |
|  | COM | **Commissioning and Closeout** |  | 2025-07-29 | 2025-09-12 |  |  |
| COM-FLUSH |  | System Flush and Chlorination | 5d | 2025-07-29 | 2025-08-06 | MEC-TEST, MS-ENERG | 0d |
| COM-LOOP |  | Instrument Loop Checks | 8d | 2025-08-06 | 2025-08-18 | COM-FLUSH | 0d |
| COM-FUNC |  | Functional Testing All Modes | 10d | 2025-08-18 | 2025-09-02 | COM-LOOP | 0d |
| COM-PERF |  | Performance and Capacity Demonstration | 5d | 2025-09-02 | 2025-09-09 | COM-FUNC | 0d |
| COM-DEMOB |  | Demobilize and Turnover Documentation | 3d | 2025-09-09 | 2025-09-12 | COM-PERF | 0d |
| MS-SC |  | Substantial Completion | 0d | 2025-09-12 | 2025-09-12 | COM-DEMOB, BLD-DOOR | 0d |

## Version 2 (data date 2025-03-31, saved 2026-08-17, file CEDARLINE-U1-2025-03-31.xer)

Last finish 2025-09-12 → 2025-09-24 (+12d). Complete tasks 0 → 8.

Changed:

| ID | Task | Start | Finish | Duration | Complete | Total float |
| --- | --- | --- | --- | --- | --- | --- |
| MS-NTP | Notice to Proceed | 2025-02-03 A | 2025-02-03 A |  | 0% → 100% | 0d → none |
| PRE-MOB | Mobilize Site Offices and Laydown | 2025-02-03 A | 2025-02-10 A |  | 0% → 100% | 17d → none |
| PRE-PERMIT | Building Permit Issuance | 2025-02-03 A | 2025-03-04 A |  | 0% → 100% | 0d → none |
| PRE-SHOP | Structural Shop Drawings and Review | 2025-02-03 A | 2025-02-25 A |  | 0% → 100% | 27d → none |
| CIV | **Civil and Structural** |  | 2025-05-30 → 2025-06-11 (+12d) |  |  |  |
| CIV-SOE | Shoring and Dewatering Install | 2025-02-10 A | 2025-02-21 A |  | 0% → 100% | 203d → none |
| CIV-EXC | Bulk Excavation Wet Well | 2025-03-04 A | 2025-03-18 A |  | 0% → 100% | 0d → none |
| CIV-MUD | Mud Slab and Survey Layout | 2025-03-18 A | 2025-03-24 A |  | 0% → 100% | 0d → none |
| CIV-BASE | Form Reinforce and Pour Base Slab | 2025-03-24 A | 2025-04-09 → 2025-04-22 (+13d) | 12d → 20d | 0% → 50% |  |
| CIV-WALL | Form Reinforce and Pour Wet Well Walls | 2025-04-09 → 2025-04-22 (+13d) | 2025-04-30 → 2025-05-12 (+12d) |  |  |  |
| CIV-CURE | Wall Cure and Strip Formwork | 2025-04-30 → 2025-05-12 (+12d) | 2025-05-09 → 2025-05-22 (+13d) |  |  |  |
| CIV-BKF | Backfill and Compact Around Structure | 2025-05-09 → 2025-05-22 (+13d) | 2025-05-20 → 2025-05-30 (+10d) |  |  | 2d → 4d |
| MS-CONC | Concrete Structure Complete | 2025-05-09 → 2025-05-22 (+13d) | 2025-05-09 → 2025-05-22 (+13d) |  |  |  |
| CIV-SLAB | Grade Slab and Equipment Pads | 2025-05-20 → 2025-05-30 (+10d) | 2025-05-30 → 2025-06-11 (+12d) |  |  | 4d → 2d |
| MEC | **Mechanical** |  | 2025-07-03 → 2025-07-15 (+12d) |  |  |  |
| MEC-PROC | Pump Skid Fabrication and Delivery | 2025-02-03 A |  |  | 0% → 50% | 65d → 77d |
| MEC-SET | Set Pump Skids and Grout Baseplates | 2025-05-09 → 2025-05-22 (+13d) | 2025-05-22 → 2025-06-03 (+12d) |  |  | 26d → 24d |
| MEC-PIPE | Internal Process Piping Install | 2025-05-22 → 2025-06-03 (+12d) | 2025-06-17 → 2025-06-27 (+10d) |  |  |  |
| MEC-VALVE | Valve and Actuator Install | 2025-06-17 → 2025-06-27 (+10d) | 2025-06-25 → 2025-07-08 (+13d) |  |  | 27d → 24d |
| MEC-TEST | Hydrostatic Test Process Piping | 2025-06-25 → 2025-07-08 (+13d) | 2025-07-03 → 2025-07-15 (+12d) |  |  | 26d → 27d |
| ELE | **Electrical** |  | 2025-07-29 → 2025-08-11 (+13d) |  |  |  |
| ELE-PROC | MCC and VFD Fabrication and Delivery | 2025-02-03 A | 2025-03-25 → 2025-04-10 (+16d) | 35d → 47d | 0% → 50% | 90d → 85d |
| ELE-COND | Conduit and Cable Tray Rough-In | 2025-06-03 → 2025-06-13 (+10d) | 2025-06-23 → 2025-07-04 (+11d) |  |  |  |
| ELE-MCC | Set MCC and VFD Line-Up | 2025-06-23 → 2025-07-04 (+11d) | 2025-06-30 → 2025-07-11 (+11d) |  |  |  |
| ELE-CABLE | Power and Control Cable Pull | 2025-06-30 → 2025-07-11 (+11d) | 2025-07-17 → 2025-07-29 (+12d) |  |  |  |
| ELE-TERM | Terminate and Point-to-Point Check | 2025-07-17 → 2025-07-29 (+12d) | 2025-07-29 → 2025-08-11 (+13d) |  |  |  |
| MS-ENERG | Permanent Power Energized | 2025-07-29 → 2025-08-11 (+13d) | 2025-07-29 → 2025-08-11 (+13d) |  |  |  |
| BLD | **Building Envelope** |  | 2025-06-19 → 2025-07-02 (+13d) |  |  |  |
| BLD-PROC | Pre-Engineered Building Delivery | 2025-02-03 A | 2025-03-18 A |  | 0% → 100% | 52d → none |
| BLD-ERECT | Erect Pre-Engineered Building Frame | 2025-05-09 → 2025-05-22 (+13d) | 2025-05-26 → 2025-06-05 (+10d) |  |  |  |
| BLD-ROOF | Roof Deck and Membrane | 2025-05-26 → 2025-06-05 (+10d) | 2025-06-03 → 2025-06-13 (+10d) |  |  |  |
| BLD-CLAD | Wall Cladding and Flashing | 2025-06-03 → 2025-06-13 (+10d) | 2025-06-13 → 2025-06-25 (+12d) |  |  | 87d → 85d |
| BLD-DOOR | Overhead Doors and Louvres | 2025-06-13 → 2025-06-25 (+12d) | 2025-06-19 → 2025-07-02 (+13d) |  |  | 85d → 84d |
| COM | **Commissioning and Closeout** | 2025-07-29 → 2025-08-11 (+13d) | 2025-09-12 → 2025-09-24 (+12d) |  |  |  |
| COM-FLUSH | System Flush and Chlorination | 2025-07-29 → 2025-08-11 (+13d) | 2025-08-06 → 2025-08-18 (+12d) |  |  |  |
| COM-LOOP | Instrument Loop Checks | 2025-08-06 → 2025-08-18 (+12d) | 2025-08-18 → 2025-08-28 (+10d) |  |  |  |
| COM-FUNC | Functional Testing All Modes | 2025-08-18 → 2025-08-28 (+10d) | 2025-09-02 → 2025-09-12 (+10d) |  |  |  |
| COM-PERF | Performance and Capacity Demonstration | 2025-09-02 → 2025-09-12 (+10d) | 2025-09-09 → 2025-09-19 (+10d) |  |  |  |
| COM-DEMOB | Demobilize and Turnover Documentation | 2025-09-09 → 2025-09-19 (+10d) | 2025-09-12 → 2025-09-24 (+12d) |  |  |  |
| MS-SC | Substantial Completion | 2025-09-12 → 2025-09-24 (+12d) | 2025-09-12 → 2025-09-24 (+12d) |  |  |  |

## Version 3 (data date 2025-06-30, saved 2026-08-17, file CEDARLINE-U2-2025-06-30.xer)

Last finish 2025-09-24 → 2025-10-03 (+9d). Complete tasks 8 → 19.

Changed:

| ID | Task | Start | Finish | Duration | Complete | Total float |
| --- | --- | --- | --- | --- | --- | --- |
| CIV | **Civil and Structural** |  | 2025-06-11 → 2025-06-20 (+9d) |  |  |  |
| CIV-BASE | Form Reinforce and Pour Base Slab |  | 2025-04-22 A |  | 50% → 100% | 0d → none |
| CIV-WALL | Form Reinforce and Pour Wet Well Walls | 2025-04-22 A | 2025-05-12 → 2025-05-22 A (+10d) | 14d → 21d | 0% → 100% | 0d → none |
| CIV-CURE | Wall Cure and Strip Formwork | 2025-05-12 → 2025-05-22 A (+10d) | 2025-05-22 → 2025-06-02 A (+11d) |  | 0% → 100% | 0d → none |
| CIV-BKF | Backfill and Compact Around Structure | 2025-05-22 → 2025-06-02 A (+11d) | 2025-05-30 → 2025-06-10 A (+11d) |  | 0% → 100% | 4d → none |
| MS-CONC | Concrete Structure Complete | 2025-05-22 → 2025-06-02 A (+11d) | 2025-05-22 → 2025-06-02 A (+11d) |  | 0% → 100% | 0d → none |
| CIV-SLAB | Grade Slab and Equipment Pads | 2025-05-30 → 2025-06-10 A (+11d) | 2025-06-11 → 2025-06-20 A (+9d) |  | 0% → 100% | 2d → none |
| MEC | **Mechanical** |  | 2025-07-15 → 2025-07-24 (+9d) |  |  |  |
| MEC-PROC | Pump Skid Fabrication and Delivery |  | 2025-04-01 A |  | 50% → 100% | 77d → none |
| MEC-SET | Set Pump Skids and Grout Baseplates | 2025-05-22 → 2025-06-02 A (+11d) | 2025-06-03 → 2025-06-12 A (+9d) |  | 0% → 100% | 24d → none |
| MEC-PIPE | Internal Process Piping Install | 2025-06-03 → 2025-06-12 A (+9d) | 2025-06-27 → 2025-07-09 (+12d) |  | 0% → 50% |  |
| MEC-VALVE | Valve and Actuator Install | 2025-06-27 → 2025-07-09 (+12d) | 2025-07-08 → 2025-07-17 (+9d) |  |  | 24d → 27d |
| MEC-TEST | Hydrostatic Test Process Piping | 2025-07-08 → 2025-07-17 (+9d) | 2025-07-15 → 2025-07-24 (+9d) |  |  |  |
| ELE | **Electrical** |  | 2025-08-11 → 2025-08-20 (+9d) |  |  |  |
| ELE-PROC | MCC and VFD Fabrication and Delivery |  | 2025-04-10 A |  | 50% → 100% | 85d → none |
| ELE-COND | Conduit and Cable Tray Rough-In | 2025-06-13 → 2025-06-24 A (+11d) | 2025-07-04 → 2025-07-15 (+11d) |  | 0% → 50% |  |
| ELE-MCC | Set MCC and VFD Line-Up | 2025-07-04 → 2025-07-15 (+11d) | 2025-07-11 → 2025-07-22 (+11d) |  |  |  |
| ELE-CABLE | Power and Control Cable Pull | 2025-07-11 → 2025-07-22 (+11d) | 2025-07-29 → 2025-08-08 (+10d) |  |  |  |
| ELE-TERM | Terminate and Point-to-Point Check | 2025-07-29 → 2025-08-08 (+10d) | 2025-08-11 → 2025-08-20 (+9d) |  |  |  |
| MS-ENERG | Permanent Power Energized | 2025-08-11 → 2025-08-20 (+9d) | 2025-08-11 → 2025-08-20 (+9d) |  |  |  |
| BLD | **Building Envelope** |  | 2025-07-02 → 2025-07-11 (+9d) |  |  |  |
| BLD-ERECT | Erect Pre-Engineered Building Frame | 2025-05-22 → 2025-06-02 A (+11d) | 2025-06-05 → 2025-06-16 A (+11d) |  | 0% → 100% | 0d → none |
| BLD-ROOF | Roof Deck and Membrane | 2025-06-05 → 2025-06-16 A (+11d) | 2025-06-13 → 2025-06-24 A (+11d) |  | 0% → 100% | 0d → none |
| BLD-CLAD | Wall Cladding and Flashing | 2025-06-13 → 2025-06-24 A (+11d) | 2025-06-25 → 2025-07-07 (+12d) |  | 0% → 50% | 85d → 84d |
| BLD-DOOR | Overhead Doors and Louvres | 2025-06-25 → 2025-07-07 (+12d) | 2025-07-02 → 2025-07-11 (+9d) |  |  |  |
| COM | **Commissioning and Closeout** | 2025-08-11 → 2025-08-20 (+9d) | 2025-09-24 → 2025-10-03 (+9d) |  |  |  |
| COM-FLUSH | System Flush and Chlorination | 2025-08-11 → 2025-08-20 (+9d) | 2025-08-18 → 2025-08-27 (+9d) |  |  |  |
| COM-LOOP | Instrument Loop Checks | 2025-08-18 → 2025-08-27 (+9d) | 2025-08-28 → 2025-09-09 (+12d) |  |  |  |
| COM-FUNC | Functional Testing All Modes | 2025-08-28 → 2025-09-09 (+12d) | 2025-09-12 → 2025-09-23 (+11d) |  |  |  |
| COM-PERF | Performance and Capacity Demonstration | 2025-09-12 → 2025-09-23 (+11d) | 2025-09-19 → 2025-09-30 (+11d) |  |  |  |
| COM-DEMOB | Demobilize and Turnover Documentation | 2025-09-19 → 2025-09-30 (+11d) | 2025-09-24 → 2025-10-03 (+9d) |  |  |  |
| MS-SC | Substantial Completion | 2025-09-24 → 2025-10-03 (+9d) | 2025-09-24 → 2025-10-03 (+9d) |  |  |  |

## Version 4 (data date 2025-09-30, saved 2026-08-17, file CEDARLINE-U3-2025-09-30.xer)

Last finish 2025-10-03 → 2025-10-07 (+4d). Complete tasks 19 → 32.

Changed:

| ID | Task | Start | Finish | Duration | Complete | Total float |
| --- | --- | --- | --- | --- | --- | --- |
| MEC | **Mechanical** |  | 2025-07-24 → 2025-08-01 (+8d) |  |  |  |
| MEC-PIPE | Internal Process Piping Install |  | 2025-07-09 → 2025-07-17 A (+8d) | 18d → 24d | 50% → 100% | 27d → none |
| MEC-VALVE | Valve and Actuator Install | 2025-07-09 → 2025-07-17 A (+8d) | 2025-07-17 → 2025-07-25 A (+8d) |  | 0% → 100% | 27d → none |
| MEC-TEST | Hydrostatic Test Process Piping | 2025-07-17 → 2025-07-25 A (+8d) | 2025-07-24 → 2025-08-01 A (+8d) |  | 0% → 100% | 27d → none |
| ELE | **Electrical** |  | 2025-08-20 → 2025-08-28 (+8d) |  |  |  |
| ELE-COND | Conduit and Cable Tray Rough-In |  | 2025-07-15 → 2025-07-23 A (+8d) | 14d → 20d | 50% → 100% | 0d → none |
| ELE-MCC | Set MCC and VFD Line-Up | 2025-07-15 → 2025-07-23 A (+8d) | 2025-07-22 → 2025-07-30 A (+8d) |  | 0% → 100% | 0d → none |
| ELE-CABLE | Power and Control Cable Pull | 2025-07-22 → 2025-07-30 A (+8d) | 2025-08-08 → 2025-08-18 A (+10d) |  | 0% → 100% | 0d → none |
| ELE-TERM | Terminate and Point-to-Point Check | 2025-08-08 → 2025-08-18 A (+10d) | 2025-08-20 → 2025-08-28 A (+8d) |  | 0% → 100% | 0d → none |
| MS-ENERG | Permanent Power Energized | 2025-08-20 → 2025-08-28 A (+8d) | 2025-08-20 → 2025-08-28 A (+8d) |  | 0% → 100% | 0d → none |
| BLD-CLAD | Wall Cladding and Flashing |  | 2025-07-07 A |  | 50% → 100% | 84d → none |
| BLD-DOOR | Overhead Doors and Louvres | 2025-07-07 A | 2025-07-11 A |  | 0% → 100% | 84d → none |
| COM | **Commissioning and Closeout** | 2025-08-20 → 2025-08-28 (+8d) | 2025-10-03 → 2025-10-07 (+4d) |  |  |  |
| COM-FLUSH | System Flush and Chlorination | 2025-08-20 → 2025-08-28 A (+8d) | 2025-08-27 → 2025-09-05 A (+9d) |  | 0% → 100% | 0d → none |
| COM-LOOP | Instrument Loop Checks | 2025-08-27 → 2025-09-05 A (+9d) | 2025-09-09 → 2025-09-17 A (+8d) |  | 0% → 100% | 0d → none |
| COM-FUNC | Functional Testing All Modes | 2025-09-09 → 2025-09-17 A (+8d) | 2025-09-23 → 2025-09-25 A (+2d) | 10d → 6d | 0% → 100% | 0d → none |
| COM-PERF | Performance and Capacity Demonstration | 2025-09-23 → 2025-09-25 A (+2d) | 2025-09-30 → 2025-10-02 (+2d) |  | 0% → 50% |  |
| COM-DEMOB | Demobilize and Turnover Documentation | 2025-09-30 → 2025-10-02 (+2d) | 2025-10-03 → 2025-10-07 (+4d) |  |  |  |
| MS-SC | Substantial Completion | 2025-10-03 → 2025-10-07 (+4d) | 2025-10-03 → 2025-10-07 (+4d) |  |  |  |
